# ProjectMigracionSPSAGARPAv1.0

Schedule from MS Project, 2016-01-18 to 2016-04-12, status date 2016-01-28.
Microsoft

## Calendars

- Standard: Mon-Fri 08:00-12:00, 13:00-17:00; Sat-Sun off.

## Resources

| Resource |
| --- |
| Gabriela Cejudo Vázquez |
| Juan Carlos Ortiz Zárate |
| Job Edson Ortiz Zárate |
| Fatima Itzel Ronquillo García |
| Luis Santiago López |
| Andrés Rafael Alcázar Pérez |
| Marco Antonio Herrera Gabriel |

## Schedule

| ID | WBS | Task | Duration | Start | Finish | Predecessors | Total slack | Free slack | Resources | Work | Text1 | Text2 | Text3 |
| --- | --- | --- | --- | --- | --- | --- | --- | --- | --- | --- | --- | --- | --- |
| 1 | 1 | **Mantenimiento Mayor Migración de SP 2010 a SP 2013** | 61.12d | 2016-01-18 08:00 | 2016-04-12 09:00 |  | 0d |  |  | 1732h | 0 hrs | 0% |  |
| 2 | 1.1 | **Sprint 1** | 4.5d | 2016-01-18 08:00 | 2016-01-22 12:00 |  | 0d |  |  | 36h | 0 hrs | 0% | Visión y alcance |
| 3 | 1.1.1 | Revisión a detalle de la propuesta de solución con Líder SAGARPA | 24h | 2016-01-18 08:00 | 2016-01-20 17:00 |  | 0d |  | Job Edson Ortiz Zárate | 24h | 24 hrs | 100% | Visión y alcance |
| 4 | 1.1.2 | Actualización de Plan de Trabajo detallado | 8h | 2016-01-21 08:00 | 2016-01-21 17:00 | 3 | 0d |  | Job Edson Ortiz Zárate | 8h | 8 hrs | 100% | Visión y alcance |
| 5 | 1.1.3 | Creación de documento APTI11-DO- Plantilla Matriz Control de Riesgos | 1h | 2016-01-22 08:00 | 2016-01-22 09:00 | 4 | 0d |  | Job Edson Ortiz Zárate | 1h | 1 hrs | 100% | Visión y alcance |
| 6 | 1.1.4 | **Entrega** | 0.38d | 2016-01-22 09:00 | 2016-01-22 12:00 | 5 | 0d |  |  | 3h | 0 hrs | 0% | Visión y alcance |
| 7 | 1.1.4.1 | Entrega Propuesta de solución con Líder SAGARPA | 1h | 2016-01-22 09:00 | 2016-01-22 10:00 |  | 0d |  | Job Edson Ortiz Zárate | 1h | 1 hrs | 100% | Visión y alcance |
| 8 | 1.1.4.2 | Entrega Plan de Trabajo detallado | 1h | 2016-01-22 10:00 | 2016-01-22 11:00 | 7 | 0d |  | Job Edson Ortiz Zárate | 1h | 1 hrs | 100% | Visión y alcance |
| 9 | 1.1.4.3 | Entrega APTI11-DO- Plantilla Matriz Control de Riesgos | 1h | 2016-01-22 11:00 | 2016-01-22 12:00 | 8 | 0d |  | Job Edson Ortiz Zárate | 1h | 1 hrs | 100% | Visión y alcance |
| 10 | 1.1 | **Sprint 2** | 45d | 2016-01-22 13:00 | 2016-03-25 12:00 | 2 | 0d |  |  | 747h | 0 hrs | 0% | Planeación |
| 11 | 1.2.1 | Creación de ATC01-DO- Requerimientos de la solución tecnológica | 2h | 2016-01-22 13:00 | 2016-01-22 15:00 |  | 54.5d | 0d | Job Edson Ortiz Zárate | 2h | 2 hrs | 100% | Planeación |
| 12 | 1.2.2 | Creación de Plan de Migración | 14h | 2016-01-22 15:00 | 2016-01-26 12:00 | 11 | 54.5d | 0d | Job Edson Ortiz Zárate | 14h | 14 hrs | 100% | Planeación |
| 13 | 1.2.3 | **Entrega** | 0.12d | 2016-01-26 13:00 | 2016-01-26 14:00 | 12 | 54.5d |  |  | 1h | 0 hrs | 0% | Planeación |
| 14 | 1.2.3.1 | Entrega ATC01-DO- Requerimientos de la solución tecnológica | 0.5h | 2016-01-26 13:00 | 2016-01-26 13:30 |  | 54.5d | 0d | Job Edson Ortiz Zárate | 0.5h | 1 hrs | 100% | Planeación |
| 15 | 1.2.3.2 | Entrega de Plan de Migración | 0.5h | 2016-01-26 13:30 | 2016-01-26 14:00 | 14 | 54.5d |  | Job Edson Ortiz Zárate | 0.5h | 1 hrs | 100% | Planeación |
| 16 | 1.2.4 | **Planeación de SQL servers** | 11d | 2016-01-22 13:00 | 2016-02-08 12:00 |  | 15d | 0d |  | 88h | 0 hrs | 0% | Planeación |
| 17 | 1.2.4.1 | Desarrollo de documento de planeación de servidores de SQL | 80h | 2016-01-22 13:00 | 2016-02-05 12:00 |  | 15d | 0d | Juan Carlos Ortiz Zárate | 80h | 34 hrs | 43% | Planeación |
| 18 | 1.2.4.2 | Entrega de documento de planeación de servidores SQL | 8h | 2016-02-05 13:00 | 2016-02-08 12:00 | 17 | 15d |  | Job Edson Ortiz Zárate | 8h | 0 hrs | 0% | Planeación |
| 19 | 1.2.5 | **Planeación de respaldos y restauración de bases de datos - SQL** | 6d | 2016-02-08 13:00 | 2016-02-16 12:00 | 16 | 15d | 0d |  | 48h | 0 hrs | 0% | Planeación |
| 20 | 1.2.5.1 | Desarrollo de documento de Planeación de respaldos y restauración de bases de datos - SQL | 40h | 2016-02-08 13:00 | 2016-02-15 12:00 |  | 15d | 0d | Juan Carlos Ortiz Zárate | 40h | 0 hrs | 0% | Planeación |
| 21 | 1.2.5.2 | Entrega de documento de Planeación de respaldos y restauración de bases de datos - SQL | 8h | 2016-02-15 13:00 | 2016-02-16 12:00 | 20 | 15d |  | Job Edson Ortiz Zárate | 8h | 0 hrs | 0% | Planeación |
| 22 | 1.2.6 | **Planeación SharePoint Server** | 11d | 2016-01-22 13:00 | 2016-02-08 12:00 |  | 0d |  |  | 88h | 0 hrs | 0% | Planeación |
| 23 | 1.2.6.1 | Desarrollo de documento de Planeación de SharePoint Server | 80h | 2016-01-22 13:00 | 2016-02-05 12:00 |  | 0d |  | Gabriela Cejudo Vázquez | 80h | 34 hrs | 43% | Planeación |
| 24 | 1.2.6.2 | Entrega de documento de SharePoint Server | 8h | 2016-02-05 13:00 | 2016-02-08 12:00 | 23 | 0d |  | Job Edson Ortiz Zárate | 8h | 0 hrs | 0% | Planeación |

| ID | WBS | Task | Duration | Start | Finish | Predecessors | Total slack | Free slack | Resources | Work | Text1 | Text2 | Text3 |
| --- | --- | --- | --- | --- | --- | --- | --- | --- | --- | --- | --- | --- | --- |
| 25 | 1.2.7 | **Planeación de Servicios** | 11d | 2016-02-08 13:00 | 2016-02-23 12:00 | 22 | 0d |  |  | 88h | 0 hrs | 0% | Planeación |
| 26 | 1.2.7.1 | Desarrollo de documento de Planeación de Servicios | 80h | 2016-02-08 13:00 | 2016-02-22 12:00 |  | 0d |  | Gabriela Cejudo Vázquez | 80h | 0 hrs | 0% | Planeación |
| 27 | 1.2.7.2 | Entrega de documento de Servicios | 8h | 2016-02-22 13:00 | 2016-02-23 12:00 | 26 | 0d |  | Job Edson Ortiz Zárate | 8h | 0 hrs | 0% | Planeación |
| 28 | 1.2.8 | **Planeación de configuración de servicios** | 9d | 2016-01-22 13:00 | 2016-02-04 12:00 |  | 11.62d | 0d |  | 72h | 0 hrs | 0% | Planeación |
| 29 | 1.2.8.1 | Desarrollo de documento de Planeación de configuración de servicios | 64h | 2016-01-22 13:00 | 2016-02-03 12:00 |  | 11.62d | 0d | Fatima Itzel Ronquillo García | 64h | 32 hrs | 50% | Planeación |
| 30 | 1.2.8.2 | Entrega de documento de configuración de servicios | 8h | 2016-02-03 13:00 | 2016-02-04 12:00 | 29 | 11.62d |  | Job Edson Ortiz Zárate | 8h | 0 hrs | 0% | Planeación |
| 31 | 1.2.9 | **Planeación de SharePoint Backups (configuración)** | 9d | 2016-02-04 13:00 | 2016-02-17 12:00 | 28 | 11.62d | 0d |  | 72h | 0 hrs | 0% | Planeación |
| 32 | 1.2.9.1 | Desarrollo de documento de Planeación de SharePoint Backups (configuración) | 64h | 2016-02-04 13:00 | 2016-02-16 12:00 |  | 11.62d | 0d | Fatima Itzel Ronquillo García | 64h | 0 hrs | 0% | Planeación |
| 33 | 1.2.9.2 | Entrega de documento de SharePoint Backups (configuración) | 8h | 2016-02-16 13:00 | 2016-02-17 12:00 | 32 | 11.62d |  | Job Edson Ortiz Zárate | 8h | 0 hrs | 0% | Planeación |
| 34 | 1.2.10 | **Planeación de proceso de migración** | 27d | 2016-02-17 13:00 | 2016-03-25 12:00 | 31 | 11.62d |  |  | 224h | 0 hrs | 0% | Planeación |
| 35 | 1.2.10.1 | Instalación de ambiente de desarrollo | 40h | 2016-02-17 13:00 | 2016-02-24 12:00 |  | 11.62d | 0d | Fatima Itzel Ronquillo García | 40h | 0 hrs | 0% | Planeación |
| 36 | 1.2.10.2 | Creación de aplicaciones web | 24h | 2016-02-24 13:00 | 2016-02-29 12:00 | 35 | 11.62d | 0d | Fatima Itzel Ronquillo García | 24h | 0 hrs | 0% | Planeación |
| 37 | 1.2.10.3 | Configuración metodos de autenticación | 20h | 2016-02-29 13:00 | 2016-03-02 17:00 | 36 | 11.62d | 0d | Fatima Itzel Ronquillo García | 20h | 0 hrs | 0% | Planeación |
| 38 | 1.2.10.4 | Configuración de accesos alternos | 16h | 2016-03-03 08:00 | 2016-03-04 17:00 | 37 | 11.62d | 0d | Fatima Itzel Ronquillo García | 16h | 0 hrs | 0% | Planeación |
| 39 | 1.2.10.5 | Creación de rutas administradas | 24h | 2016-03-07 08:00 | 2016-03-09 17:00 | 38 | 11.62d | 0d | Fatima Itzel Ronquillo García | 24h | 0 hrs | 0% | Planeación |
| 40 | 1.2.10.6 | Configuración de correo electrónico | 4h | 2016-03-10 08:00 | 2016-03-10 12:00 | 39 | 11.62d | 0d | Fatima Itzel Ronquillo García | 4h | 0 hrs | 0% | Planeación |
| 41 | 1.2.10.7 | Documentación de instalación y configuración de ambiente de desarrollo | 88h | 2016-03-10 13:00 | 2016-03-25 12:00 | 40 | 11.62d |  | Fatima Itzel Ronquillo García | 88h | 0 hrs | 0% |  |
| 42 | 1.2.10.8 | Entrega de Manual de proceso de migración | 8h | 2016-03-10 13:00 | 2016-03-11 12:00 | 40 | 21.62d |  | Job Edson Ortiz Zárate | 8h | 0 hrs | 0% | Planeación |
| 43 | 1.2.11 | **Planeación de sustitución de desarrollos** | 2.25d | 2016-01-22 13:00 | 2016-01-26 15:00 |  | 2.75d | 0d |  | 18h | 0 hrs | 0% | Planeación |
| 44 | 1.2.11.1 | Desarrollo de documento de Planeación de sustitución de desarrollos | 16h | 2016-01-22 13:00 | 2016-01-26 12:00 |  | 2.75d | 0d | Luis Santiago López | 16h | 16 hrs | 100% | Planeación |
| 45 | 1.2.11.2 | Entrega de documento de sustitución de desarrollos | 2h | 2016-01-26 13:00 | 2016-01-26 15:00 | 44 | 2.75d |  | Job Edson Ortiz Zárate | 2h | 2 hrs | 100% | Planeación |
| 46 | 1.2.12 | **Planeación de migración código fuente personalizado** | 4d | 2016-01-22 13:00 | 2016-01-28 12:00 |  | 37d | 0d |  | 32h | 0 hrs | 0% | Planeación |
| 47 | 1.2.12.1 | Desarrollo de documento de Planeación de migración código fuente personalizado | 24h | 2016-01-22 13:00 | 2016-01-27 12:00 |  | 37d | 0d | Andrés Rafael Alcázar Pérez | 24h | 24 hrs | 100% | Planeación |
| 48 | 1.2.12.2 | Entrega de documento de migración código fuente personalizado | 8h | 2016-01-27 13:00 | 2016-01-28 12:00 | 47 | 37d |  | Job Edson Ortiz Zárate | 8h | 8 hrs | 100% | Planeación |

| ID | WBS | Task | Duration | Start | Finish | Predecessors | Total slack | Free slack | Resources | Work | Text1 | Text2 | Text3 |
| --- | --- | --- | --- | --- | --- | --- | --- | --- | --- | --- | --- | --- | --- |
| 49 | 1.2 | **Sprint 3** | 50.75d | 2016-01-26 15:00 | 2016-04-06 12:00 |  | 0d |  |  | 896h | 0 hrs | 0% | Desarrollo |
| 50 | 1.3.1 | **Implementación de servidores de SQL** | 21d | 2016-02-16 13:00 | 2016-03-16 12:00 | 19 | 15d |  |  | 168h | 0 hrs | 0% | Desarrollo |
| 51 | 1.3.1.1 | Instalación de servidores de SQL y desarrollo de manual | 160h | 2016-02-16 13:00 | 2016-03-15 12:00 |  | 15d | 0d | Juan Carlos Ortiz Zárate | 160h | 0 hrs | 0% | Desarrollo |
| 52 | 1.3.1.2 | Entrega de manual de instalación de servidores SQL | 8h | 2016-03-15 13:00 | 2016-03-16 12:00 | 51 | 15d |  | Job Edson Ortiz Zárate | 8h | 0 hrs | 0% | Desarrollo |
| 53 | 1.3.2 | **Implementación de servidores de sharepoint** | 21d | 2016-02-23 13:00 | 2016-03-23 12:00 | 25 | 0d |  |  | 168h | 0 hrs | 0% | Desarrollo |
| 54 | 1.3.2.1 | Instalación de servidores sharepoint y desarrollo de manual | 160h | 2016-02-23 13:00 | 2016-03-22 12:00 |  | 0d |  | Gabriela Cejudo Vázquez | 160h | 0 hrs | 0% | Desarrollo |
| 55 | 1.3.2.2 | Entrega de manual de instalación de servidores sharepoint | 8h | 2016-03-22 13:00 | 2016-03-23 12:00 | 54 | 0d |  | Job Edson Ortiz Zárate | 8h | 0 hrs | 0% | Desarrollo |
| 56 | 1.3.3 | **Desarrollo de componentes para sustitución de desarrollos HOME** | 48d | 2016-01-26 15:00 | 2016-04-01 15:00 | 43 | 2.75d |  |  | 384h | 0 hrs | 0% | Desarrollo |
| 57 | 1.3.3.1 | Desarrollo 1 | 102h | 2016-01-26 15:00 | 2016-02-12 12:00 |  | 2.75d | 0d | Luis Santiago López | 102h | 12 hrs | 12% | Desarrollo |
| 58 | 1.3.3.2 | Desarrollo 2 | 80h | 2016-02-12 13:00 | 2016-02-26 12:00 | 57 | 2.75d | 0d | Luis Santiago López | 80h | 0 hrs | 0% | Desarrollo |
| 59 | 1.3.3.3 | Desarrollo 3 | 120h | 2016-02-26 13:00 | 2016-03-18 12:00 | 58 | 2.75d | 0d | Luis Santiago López | 120h | 0 hrs | 0% | Desarrollo |
| 60 | 1.3.3.4 | Desarrollo 4 | 40h | 2016-03-18 13:00 | 2016-03-25 12:00 | 59 | 2.75d | 0d | Luis Santiago López | 40h | 0 hrs | 0% | Desarrollo |
| 61 | 1.3.3.5 | Desarrollo 5 | 40h | 2016-03-25 13:00 | 2016-04-01 12:00 | 60 | 2.75d | 0d | Luis Santiago López | 40h | 0 hrs | 0% | Desarrollo |
| 62 | 1.3.3.6 | Entrega de Manual de componentes para sustitución de desarrollos HOME | 2h | 2016-04-01 13:00 | 2016-04-01 15:00 | 61 | 2.75d |  | Job Edson Ortiz Zárate | 2h | 0 hrs | 0% | Desarrollo |
| 63 | 1.3.4 | **Migración de personalizaciones** | 12d | 2016-01-28 13:00 | 2016-02-15 12:00 | 46 | 37d |  |  | 96h | 0 hrs | 0% | Desarrollo |
| 64 | 1.3.4.1 | Migración 1 | 10h | 2016-01-28 13:00 | 2016-01-29 15:00 |  | 37d | 0d | Andrés Rafael Alcázar Pérez | 10h | 0 hrs | 0% | Desarrollo |
| 65 | 1.3.4.2 | Migración 2 | 10h | 2016-01-29 15:00 | 2016-02-01 17:00 | 64 | 37d | 0d | Andrés Rafael Alcázar Pérez | 10h | 0 hrs | 0% | Desarrollo |
| 66 | 1.3.4.3 | Migración 3 | 10h | 2016-02-02 08:00 | 2016-02-03 10:00 | 65 | 37d | 0d | Andrés Rafael Alcázar Pérez | 10h | 0 hrs | 0% | Desarrollo |
| 67 | 1.3.4.4 | Migración 4 | 10h | 2016-02-03 10:00 | 2016-02-04 12:00 | 66 | 37d | 0d | Andrés Rafael Alcázar Pérez | 10h | 0 hrs | 0% | Desarrollo |
| 68 | 1.3.4.5 | Migración 5 | 10h | 2016-02-04 13:00 | 2016-02-05 15:00 | 67 | 37d | 0d | Andrés Rafael Alcázar Pérez | 10h | 0 hrs | 0% | Desarrollo |
| 69 | 1.3.4.6 | Manual de procedimiento de instalación de personalizaciones | 44h | 2016-02-05 15:00 | 2016-02-15 10:00 | 68 | 37d | 0d | Andrés Rafael Alcázar Pérez | 44h | 0 hrs | 0% | Desarrollo |
| 70 | 1.3.4.7 | Entrega de procedimiento de instalación de personalizaciones | 0.25d | 2016-02-15 10:00 | 2016-02-15 12:00 | 69 | 37d |  | Job Edson Ortiz Zárate | 2h | 0 hrs | 0% |  |
| 71 | 1.3.5 | **Pruebas** | 10d | 2016-03-23 13:00 | 2016-04-06 12:00 | 53 | 0d |  |  | 80h | 0 hrs | 0% |  |
| 72 | 1.3.5.1 | Creación de CST01-DO-Programa de calidad | 20h | 2016-03-23 13:00 | 2016-03-25 17:00 |  | 0d |  | Marco Antonio Herrera Gabriel | 20h | 0 hrs | 0% |  |
| 73 | 1.3.5.2 | Creación de CST02-DO-Reporte de Revisión | 20h | 2016-03-28 08:00 | 2016-03-30 12:00 | 72 | 0d |  | Marco Antonio Herrera Gabriel | 20h | 0 hrs | 0% |  |
| 74 | 1.3.5.3 | Creación de CST03-DO-Escenario de Pruebas | 20h | 2016-03-30 13:00 | 2016-04-01 17:00 | 73 | 0d |  | Marco Antonio Herrera Gabriel | 20h | 0 hrs | 0% |  |
| 75 | 1.3.5.4 | Ejecución de pruebas | 20h | 2016-04-04 08:00 | 2016-04-06 12:00 | 74 | 0d |  | Marco Antonio Herrera Gabriel | 20h | 0 hrs | 0% |  |

| ID | WBS | Task | Duration | Start | Finish | Predecessors | Total slack | Free slack | Resources | Work | Text1 | Text2 | Text3 |
| --- | --- | --- | --- | --- | --- | --- | --- | --- | --- | --- | --- | --- | --- |
| 76 | 1.3 | **Sprint 4** | 3.62d | 2016-04-06 13:00 | 2016-04-12 09:00 | 49 | 0d |  |  | 53h | 0 hrs | 0% | Implementación |
| 77 | 1.4.1 | **Migración en producción** | 3.62d | 2016-04-06 13:00 | 2016-04-12 09:00 |  | 0d |  |  | 33h | 0 hrs | 0% |  |
| 78 | 1.3.1 | Copiar personalizaciones | 4h | 2016-04-06 13:00 | 2016-04-06 17:00 |  | 0d |  | Fatima Itzel Ronquillo García | 4h | 0 hrs | 0% | Implementación |
| 79 | 1.3.2 | Mover bases de datos | 4h | 2016-04-07 08:00 | 2016-04-07 12:00 | 78 | 0d |  | Fatima Itzel Ronquillo García | 4h | 0 hrs | 0% | Implementación |
| 80 | 1.3.3 | Migrar aplicaciones de servicio | 4h | 2016-04-07 13:00 | 2016-04-07 17:00 | 79 | 0d |  | Fatima Itzel Ronquillo García | 4h | 0 hrs | 0% | Implementación |
| 81 | 1.3.4 | Crear aplicaciones web | 4h | 2016-04-08 08:00 | 2016-04-08 12:00 | 80 | 0d |  | Fatima Itzel Ronquillo García | 4h | 0 hrs | 0% | Implementación |
| 82 | 1.3.5 | Adjuntar bases de datos | 13h | 2016-04-08 13:00 | 2016-04-12 09:00 | 81 | 0d |  | Fatima Itzel Ronquillo García | 13h | 0 hrs | 0% | Implementación |
| 83 | 1.4.1.6 | Creación de DST14 DO Reporte de Integración | 4h | 2016-04-06 13:00 | 2016-04-06 17:00 |  | 3.12d |  | Job Edson Ortiz Zárate | 4h | 0 hrs | 0% | Implementación |
| 84 | 1.4 | **Entregables** | 2.5d | 2016-04-06 13:00 | 2016-04-08 17:00 |  | 1.12d |  |  | 20h | 0 hrs | 0% | Implementación |
| 85 | 1.4.2.1 | Entrega de documento CST01-DO-Programa de calidad | 1h | 2016-04-06 13:00 | 2016-04-06 14:00 |  | 1.12d | 0d | Job Edson Ortiz Zárate | 1h | 0 hrs | 0% |  |
| 86 | 1.4.2.2 | Entrega de documento CST02-DO-Reporte de Revisión | 1h | 2016-04-06 14:00 | 2016-04-06 15:00 | 85 | 1.12d | 0d | Job Edson Ortiz Zárate | 1h | 0 hrs | 0% |  |
| 87 | 1.4.2.3 | Entrega de documento CST03-DO-Escenario de Pruebas | 1h | 2016-04-06 15:00 | 2016-04-06 16:00 | 86 | 1.12d | 0d | Job Edson Ortiz Zárate | 1h | 0 hrs | 0% |  |
| 88 | 1.4.2.4 | Entrega de documento resultados ejecución de pruebas | 7h | 2016-04-06 16:00 | 2016-04-07 15:00 | 87 | 1.12d | 0d | Job Edson Ortiz Zárate | 7h | 0 hrs | 0% |  |
| 89 | 1.4.2.5 | Entrega de Código Fuente y ejecutables y modificados | 2h | 2016-04-07 15:00 | 2016-04-07 17:00 | 88 | 1.12d | 0d | Job Edson Ortiz Zárate | 2h | 0 hrs | 0% | Implementación |
| 90 | 1.4.2.6 | Entrega de DST14 DO Reporte de Integración | 2h | 2016-04-08 08:00 | 2016-04-08 10:00 | 89 | 1.12d | 0d | Job Edson Ortiz Zárate | 2h | 0 hrs | 0% | Implementación |
| 91 | 1.4.20 | Entrega de APTI09-DO- Carta de Liberación | 6h | 2016-04-08 10:00 | 2016-04-08 17:00 | 90 | 1.12d |  | Job Edson Ortiz Zárate | 6h | 0 hrs | 0% | Implementación |
